# SERVICIO DE HABILITACIÓN DE ACCESOS Y PLATAFORMAS, Y MOVIMIENTO DE TIERRAS II PARTE - CUENCA CAÑETE

Schedule from Primavera P6, 2023-03-10 to 2023-11-30, data date 2023-03-10.

## Calendars

- Dos turnos - 6x1 - 10 horas: Mon-Sat 01:00-06:00, 07:00-12:00, 13:00-18:00, 19:00-00:00; Sun off. Exceptions (off unless hours are given): 2023-04-06 to 2023-04-07, 2023-05-01, 2023-06-29, 2023-07-28 to 2023-07-29, 2023-08-30, 2023-11-01.

## Schedule

| ID | WBS | Activity | Type | Duration | Start | Finish | Predecessors | Total float | Free float |
| --- | --- | --- | --- | --- | --- | --- | --- | --- | --- |
|  | 1 | **Hitos** |  |  | 2023-03-10 | 2023-11-22 |  |  |  |
| A1000 |  | Suscripción del contrato | milestone | 0d | 2023-03-10 | 2023-03-10 |  | 0d |  |
| A1010 |  | Inicio de obra - Acceso al Sitio | milestone | 0d | 2023-04-01 | 2023-04-01 | A1000 FS+19d | 0d |  |
| A1020 |  | Inicio de Habilitación y mejoramiento de accesos | milestone | 0d | 2023-04-11 | 2023-04-11 | A1160 SS+3d | 0d |  |
| A1030 |  | Inicio de Movimiento de Tierras - Diques Paquete 2 | milestone | 0d | 2023-04-21 | 2023-04-21 | A1130 SS+6d | 0d |  |
| A1050 |  | Inicio de Movimiento de Tierras - Diques Paquete 3 | milestone | 0d | 2023-06-01 | 2023-06-01 | A1010 FS+49d | 10d | 0d |
| A1040 |  | Culminación de Diques Paquete 2 | milestone | 0d | 2023-08-06 | 2023-08-06 | A1180, A1190, A1200, A1210, A1220, A1230, A1240, A1250, A1260, A1270, A1280, A1290, A1195 | 90d |  |
| A1060 |  | Culminación de Diques Paquete 3 | milestone | 0d | 2023-11-22 | 2023-11-22 | A1300, A1310, A1320, A1330, A1340, A1350, A1360, A1370, A1380, A1390, A1400, A1410, A1420, A1430, A1440, A1450, A1460, A1470, A1480, A1490, A1500, A1510, A1520, A1530, A1540, A1550, A1560, A1570, A1580, A1590, A1600, A1610, A1620, A1630, A1640, A1650, A1660, A1670, A1680, A1690, A1700, A1710, A1720, A1730, A1740, A1750, A1760, A1770, A1780, A1790, A1800, A1810, A1940, A1950, A1960, A1970, A1980, A1990, A2000, A2010, A2020, A2030, A2040, A2050, A1820, A1830, A1840, A1860, A2060, A2070, A2080, A2090, A2100, A2110, A2120, A2130, A2140, A2150, A2160, A2170, A2180, A2190, A2200, A2210, A2220, A2230, A2240, A2250, A2260, A2270, A2280, A2290, A1315, A1435, A1595 | 0d |  |
|  | 2 | **Obras Provisionales** |  |  | 2023-04-01 | 2023-11-30 |  |  |  |
| A1070 |  | Movilización |  | 26d | 2023-04-01 | 2023-05-05 | A1010 | 0d |  |
| A1080 |  | Mejoramiento y habilitación de caminos de acceso |  | 32d | 2023-04-11 | 2023-05-19 | A1020 | 0d |  |
| A1090 |  | Limpieza manual de material vegetal y de residuos |  | 32d | 2023-04-11 | 2023-05-19 | A1080 SS | 155d |  |
| A1100 |  | Tubería HDPE corrugada 630 mm |  | 29d | 2023-04-14 | 2023-05-19 | A1080 SS+3d | 155d |  |
| A1110 |  | Tubería HDPE corrugada 1000 mm |  | 29d | 2023-04-14 | 2023-05-19 | A1080 SS+3d | 155d |  |
| A1120 |  | Habilitación de plataformas |  | 26d | 2023-04-14 | 2023-05-16 | A1130 SS | 158d |  |
| A1130 |  | Campamento Provisional de Obra |  | 26d | 2023-04-14 | 2023-05-16 | A1080 SS+3d | 0d |  |
| A1140 |  | Mantenimiento de caminos de acceso |  | 183d | 2023-04-14 | 2023-11-21 | A1080 SS+3d | 1d |  |
| A1150 |  | Desmovilización |  | 7d | 2023-11-22 | 2023-11-30 | A1140, A1060, A2300, A2660, A2700, A2710, A1090, A1100, A1110, A1120, A1170, A1040 | 0d |  |
|  | 3 | **Topografía** |  |  | 2023-04-05 | 2023-11-21 |  |  |  |
| A1160 |  | Trazo y replanteo inicial |  | 26d | 2023-04-05 | 2023-05-09 | A1070 SS+3d | 0d |  |
| A1170 |  | Trazo y replanteo durante la obra |  | 163d | 2023-05-09 | 2023-11-21 | A1160 | 1d |  |
|  | 4 | **Paquete 2** |  |  | 2023-04-21 | 2023-08-06 |  |  |  |
|  | 1 | **DE-PR-07-I** |  |  | 2023-04-21 | 2023-08-06 |  |  |  |
|  | 1 | **Excavaciones** |  |  | 2023-04-21 | 2023-06-09 |  |  |  |
| A1180 |  | Desbroce |  | 38d | 2023-04-21 | 2023-06-06 | A1030 | 0d |  |
| A1190 |  | Excavación de cimentación |  | 38d | 2023-04-21 | 2023-06-06 | A1180 SS | 0d |  |
| A1195 |  | Excavación localizada - Sobreexcavación |  | 38d | 2023-04-21 | 2023-06-06 | A1190 SS | 140d | 50d |
| A1200 |  | Perfilado y conformación de plataforma de fundación |  | 38d | 2023-04-25 | 2023-06-09 | A1190 SS+3d | 96d | 0d |
| A1210 |  | Excavación de uña |  | 34d | 2023-04-28 | 2023-06-08 | A1190 SS+6d | 0d |  |

| ID | WBS | Activity | Duration | Start | Finish | Predecessors | Total float | Free float |
| --- | --- | --- | --- | --- | --- | --- | --- | --- |
|  | 2 | **Rellenos** |  | 2023-05-03 | 2023-08-06 |  |  |  |
| A1220 |  | Relleno con material granular | 46d | 2023-05-03 | 2023-06-25 | A1210 SS+3d | 0d |  |
| A1225 |  | Relleno con material seleccionado | 46d | 2023-05-03 | 2023-06-25 | A1220 SS | 130d |  |
| A1230 |  | Perfilado de Talud del dique | 35d | 2023-05-17 | 2023-06-27 | A1220 SS+12d | 0d |  |
| A1240 |  | Relleno sin compactar | 18d | 2023-06-27 | 2023-07-19 | A1280 | 93d | 0d |
| A1255 |  | Grava para drenaje | 3d | 2023-07-19 | 2023-07-22 | A1220, A1240 | 93d | 0d |
| A1250 |  | Relleno afirmado | 6d | 2023-07-31 | 2023-08-06 | A1290 | 79d | 0d |
|  | 3 | **Geotextil** |  | 2023-05-03 | 2023-07-01 |  |  |  |
| A1260 |  | Instalación de Geotextil - uña | 32d | 2023-05-03 | 2023-06-09 | A1210 SS+3d | 0d |  |
| A1270 |  | Instalación de Geotextil - Talud | 32d | 2023-05-24 | 2023-07-01 | A1230 SS+6d | 0d |  |
|  | 4 | **Colocación de Roca** |  | 2023-05-06 | 2023-07-28 |  |  |  |
| A1280 |  | Colocación de roca de uña | 44d | 2023-05-06 | 2023-06-27 | A1260 SS+3d | 0d |  |
| A1290 |  | Colocación de roca de talud | 52d | 2023-05-27 | 2023-07-28 | A1270 SS+3d | 0d |  |
|  | 5 | **Paquete 3** |  | 2023-06-01 | 2023-11-22 |  |  |  |
|  | 1 | **DI-PD-18-I** |  | 2023-06-06 | 2023-08-20 |  |  |  |
|  | 1 | **Excavaciones** |  | 2023-06-06 | 2023-06-28 |  |  |  |
| A1300 |  | Desbroce | 13d | 2023-06-06 | 2023-06-21 | A1180, A1050 | 6d | 0d |
| A1310 |  | Excavación de cimentación | 13d | 2023-06-06 | 2023-06-21 | A1300 SS, A1190 | 6d | 0d |
| A1315 |  | Excavación localizada - Sobreexcavación | 13d | 2023-06-06 | 2023-06-21 | A1310 SS | 127d |  |
| A1320 |  | Perfilado y conformación de plataforma de fundación | 11d | 2023-06-09 | 2023-06-22 | A1310 SS+3d, A1200 | 96d | 2d |
| A1330 |  | Excavación de uña | 13d | 2023-06-13 | 2023-06-28 | A1310 SS+6d, A1210 | 6d | 0d |
|  | 2 | **Rellenos** |  | 2023-06-26 | 2023-08-20 |  |  |  |
| A1340 |  | Relleno con material granular | 21d | 2023-06-26 | 2023-07-21 | A1330 SS+3d, A1220 | 0d |  |
| A1345 |  | Relleno con material seleccionado | 21d | 2023-06-26 | 2023-07-21 | A1340 SS | 109d |  |
| A1350 |  | Perfilado de Talud del dique | 12d | 2023-07-11 | 2023-07-25 | A1340 SS+12d, A1230 | 6d | 0d |
| A1360 |  | Relleno sin compactar | 8d | 2023-07-22 | 2023-08-03 | A1255 | 93d | 0d |
| A1850 |  | Grava para drenaje | 2d | 2023-08-03 | 2023-08-05 | A1340, A1360 | 98d |  |
| A1370 |  | Relleno afirmado | 3d | 2023-08-17 | 2023-08-20 | A1250, A1410 | 70d | 42d |

| ID | WBS | Activity | Duration | Start | Finish | Predecessors | Total float | Free float |
| --- | --- | --- | --- | --- | --- | --- | --- | --- |
|  | 3 | **Geotextil** |  | 2023-06-16 | 2023-08-02 |  |  |  |
| A1380 |  | Instalación de Geotextil - uña | 11d | 2023-06-16 | 2023-06-29 | A1330 SS+3d, A1260 | 6d | 2d |
| A1390 |  | Instalación de Geotextil - Talud | 11d | 2023-07-18 | 2023-08-02 | A1350 SS+6d, A1270 | 6d |  |
|  | 4 | **Colocación de Roca** |  | 2023-06-27 | 2023-08-17 |  |  |  |
| A1400 |  | Colocación de roca de uña | 23d | 2023-06-27 | 2023-07-25 | A1380 SS+3d, A1280 | 0d |  |
| A1410 |  | Colocación de roca de talud | 15d | 2023-07-31 | 2023-08-17 | A1390 SS+3d, A1290 | 0d |  |
|  | 2 | **DI-PR-19BIS-I** |  | 2023-06-21 | 2023-10-19 |  |  |  |
|  | 1 | **Excavaciones** |  | 2023-06-21 | 2023-08-17 |  |  |  |
| A1420 |  | Desbroce | 32d | 2023-06-21 | 2023-08-01 | A1300 | 16d | 0d |
| A1430 |  | Excavación de cimentación | 32d | 2023-06-21 | 2023-08-01 | A1420 SS, A1310 | 16d | 0d |
| A1435 |  | Excavación localizada - Sobreexcavación | 32d | 2023-06-21 | 2023-08-01 | A1430 SS | 95d |  |
| A1440 |  | Perfilado y conformación de plataforma de fundación | 30d | 2023-06-24 | 2023-08-02 | A1430 SS+3d, A1320 | 94d |  |
| A1450 |  | Excavación de uña | 40d | 2023-06-28 | 2023-08-17 | A1430 SS+6d, A1330 | 16d | 0d |
|  | 2 | **Rellenos** |  | 2023-07-21 | 2023-10-19 |  |  |  |
| A1460 |  | Relleno con material granular | 49d | 2023-07-21 | 2023-09-20 | A1450 SS+3d, A1340 | 0d |  |
| A1465 |  | Relleno con material seleccionado | 49d | 2023-07-21 | 2023-09-20 | A1460 SS | 60d |  |
| A1470 |  | Perfilado de Talud del dique | 38d | 2023-08-07 | 2023-09-21 | A1460 SS+12d, A1350 | 0d |  |
| A1480 |  | Relleno sin compactar | 21d | 2023-09-20 | 2023-10-14 | A1460 | 32d | 0d |
| A1490 |  | Relleno afirmado | 8d | 2023-10-10 | 2023-10-19 | A1530, A1370 | 28d |  |
| A1870 |  | Grava para drenaje | 4d | 2023-10-14 | 2023-10-19 | A1460, A1480 | 35d |  |
|  | 3 | **Geotextil** |  | 2023-07-03 | 2023-09-19 |  |  |  |
| A1500 |  | Instalación de Geotextil - uña | 38d | 2023-07-03 | 2023-08-18 | A1450 SS+3d, A1380 | 16d |  |
| A1510 |  | Instalación de Geotextil - Talud | 30d | 2023-08-14 | 2023-09-19 | A1470 SS+6d, A1390 | 0d |  |
|  | 4 | **Colocación de Roca** |  | 2023-07-25 | 2023-10-10 |  |  |  |
| A1520 |  | Colocación de roca de uña | 60d | 2023-07-25 | 2023-10-06 | A1500 SS+3d, A1400 | 0d |  |
| A1530 |  | Colocación de roca de talud | 45d | 2023-08-17 | 2023-10-10 | A1510 SS+3d, A1410 | 0d |  |

| ID | WBS | Activity | Duration | Start | Finish | Predecessors | Total float | Free float |
| --- | --- | --- | --- | --- | --- | --- | --- | --- |
|  | 3 | **DI-PR-39-I (22 Espigones)** |  | 2023-08-01 | 2023-11-22 |  |  |  |
|  | 1 | **Excavaciones** |  | 2023-08-01 | 2023-09-06 |  |  |  |
| A1540 |  | Desbroce | 30d | 2023-08-01 | 2023-09-06 | A1420 | 65d | 0d |
| A1550 |  | Excavación bajo nivel freático | 30d | 2023-08-01 | 2023-09-06 | A1540 SS, A1430 | 65d |  |
|  | 2 | **Colocación de Roca** |  | 2023-10-06 | 2023-11-22 |  |  |  |
| A1560 |  | Colocación de roca de uña | 36d | 2023-10-06 | 2023-11-18 | A1520 | 0d |  |
| A1570 |  | Colocación de roca de talud | 36d | 2023-10-10 | 2023-11-22 | A1530, A1560 SS+3d | 0d |  |
|  | 4 | **DE-PR-45-D** |  | 2023-06-01 | 2023-06-27 |  |  |  |
|  | 1 | **Excavaciones** |  | 2023-06-01 | 2023-06-13 |  |  |  |
| A1580 |  | Desbroce | 3d | 2023-06-01 | 2023-06-04 | A1050 | 14d | 0d |
| A1590 |  | Excavación de cimentación | 3d | 2023-06-01 | 2023-06-04 | A1580 SS | 14d | 0d |
| A1595 |  | Excavación localizada - Sobreexcavación | 3d | 2023-06-01 | 2023-06-04 | A1590 SS | 141d |  |
| A1600 |  | Perfilado y conformación de plataforma de fundación | 2d | 2023-06-05 | 2023-06-07 | A1590 | 36d | 1d |
| A1610 |  | Excavación de uña | 7d | 2023-06-05 | 2023-06-13 | A1590 | 14d | 0d |
|  | 2 | **Rellenos** |  | 2023-06-08 | 2023-06-27 |  |  |  |
| A1620 |  | Relleno con material granular | 3d | 2023-06-08 | 2023-06-11 | A1610 SS+3d | 21d | 0d |
| A1625 |  | Relleno con material seleccionado | 3d | 2023-06-08 | 2023-06-11 | A1620 SS | 142d |  |
| A1630 |  | Perfilado de Talud del dique | 3d | 2023-06-12 | 2023-06-15 | A1620 | 54d | 0d |
| A1640 |  | Relleno sin compactar | 3d | 2023-06-20 | 2023-06-23 | A1680 | 68d | 0d |
| A1650 |  | Relleno afirmado | 3d | 2023-06-22 | 2023-06-25 | A1690 | 109d | 20d |
| A1880 |  | Grava para drenaje | 3d | 2023-06-23 | 2023-06-27 | A1640 | 68d | 16d |
|  | 3 | **Geotextil** |  | 2023-06-08 | 2023-06-17 |  |  |  |
| A1660 |  | Instalación de Geotextil - uña | 5d | 2023-06-08 | 2023-06-14 | A1610 SS+3d | 52d | 0d |
| A1670 |  | Instalación de Geotextil - Talud | 2d | 2023-06-15 | 2023-06-17 | A1630 SS+3d | 95d | 0d |

| ID | WBS | Activity | Duration | Start | Finish | Predecessors | Total float | Free float |
| --- | --- | --- | --- | --- | --- | --- | --- | --- |
|  | 4 | **Colocación de Roca** |  | 2023-06-12 | 2023-06-22 |  |  |  |
| A1680 |  | Colocación de roca de uña | 7d | 2023-06-12 | 2023-06-20 | A1660 SS+3d | 52d | 0d |
| A1690 |  | Colocación de roca de talud | 3d | 2023-06-19 | 2023-06-22 | A1670 SS+3d | 95d | 0d |
|  | 5 | **DI-PD-44-D** |  | 2023-06-05 | 2023-08-01 |  |  |  |
|  | 1 | **Excavaciones** |  | 2023-06-05 | 2023-07-05 |  |  |  |
| A1700 |  | Desbroce | 9d | 2023-06-05 | 2023-06-15 | A1580 | 15d | 0d |
| A1710 |  | Excavación de cimentación | 9d | 2023-06-05 | 2023-06-15 | A1700 SS, A1590 | 15d | 0d |
| A1715 |  | Excavación localizada - Sobreexcavación | 9d | 2023-06-05 | 2023-06-15 | A1710 SS | 139d |  |
| A1720 |  | Perfilado y conformación de plataforma de fundación | 7d | 2023-06-08 | 2023-06-16 | A1710 SS+3d, A1600 | 35d | 2d |
| A1730 |  | Excavación de uña | 18d | 2023-06-13 | 2023-07-05 | A1710 SS+6d, A1610 | 14d | 0d |
|  | 2 | **Rellenos** |  | 2023-06-16 | 2023-08-01 |  |  |  |
| A1740 |  | Relleno con material granular | 15d | 2023-06-16 | 2023-07-05 | A1730 SS+3d, A1620 | 17d | 0d |
| A1745 |  | Relleno con material seleccionado | 15d | 2023-06-16 | 2023-07-05 | A1740 SS | 123d |  |
| A1750 |  | Perfilado de Talud del dique | 10d | 2023-06-23 | 2023-07-06 | A1740 SS+6d, A1630 | 47d | 0d |
| A1760 |  | Relleno sin compactar | 8d | 2023-07-17 | 2023-07-26 | A1800, A1880 | 52d | 0d |
| A1770 |  | Relleno afirmado | 3d | 2023-07-20 | 2023-07-23 | A1810, A1650 | 89d | 15d |
| A1890 |  | Grava para drenaje | 3d | 2023-07-26 | 2023-08-01 | A1880, A1760 | 52d | 0d |
|  | 3 | **Geotextil** |  | 2023-06-16 | 2023-07-05 |  |  |  |
| A1780 |  | Instalación de Geotextil - uña | 15d | 2023-06-16 | 2023-07-05 | A1730 SS+3d, A1660 | 52d | 0d |
| A1790 |  | Instalación de Geotextil - Talud | 3d | 2023-07-01 | 2023-07-05 | A1750 SS+6d, A1670 | 85d | 0d |
|  | 4 | **Colocación de Roca** |  | 2023-06-20 | 2023-07-20 |  |  |  |
| A1800 |  | Colocación de roca de uña | 22d | 2023-06-20 | 2023-07-16 | A1780 SS+3d, A1680 | 52d | 0d |
| A1810 |  | Colocación de roca de talud | 13d | 2023-07-05 | 2023-07-20 | A1790 SS+3d, A1690 | 85d | 0d |
|  | 6 | **DI-PR-41-D** |  | 2023-06-15 | 2023-08-16 |  |  |  |
|  | 1 | **Excavaciones** |  | 2023-06-15 | 2023-07-09 |  |  |  |
| A1940 |  | Desbroce | 6d | 2023-06-15 | 2023-06-22 | A1700 | 23d | 0d |
| A1950 |  | Excavación de cimentación | 6d | 2023-06-15 | 2023-06-22 | A1940 SS, A1710 | 23d | 0d |
| A1955 |  | Excavación localizada - Sobreexcavación | 6d | 2023-06-15 | 2023-06-22 | A1950 SS | 133d |  |
| A1960 |  | Perfilado y conformación de plataforma de fundación | 4d | 2023-06-19 | 2023-06-23 | A1950 SS+3d, A1720 | 33d | 2d |
| A1970 |  | Excavación de uña | 4d | 2023-07-05 | 2023-07-09 | A1950 SS+6d, A1730 | 14d | 0d |

| ID | WBS | Activity | Duration | Start | Finish | Predecessors | Total float | Free float |
| --- | --- | --- | --- | --- | --- | --- | --- | --- |
|  | 2 | **Rellenos** |  | 2023-07-08 | 2023-08-16 |  |  |  |
| A1980 |  | Relleno con material granular | 9d | 2023-07-08 | 2023-07-19 | A1970 SS+3d, A1740 | 14d | 0d |
| A1985 |  | Relleno con material seleccionado | 9d | 2023-07-08 | 2023-07-19 | A1980 SS | 111d |  |
| A1990 |  | Perfilado de Talud del dique | 4d | 2023-07-22 | 2023-07-27 | A1980 SS+12d, A1750 | 33d | 0d |
| A2000 |  | Relleno sin compactar | 3d | 2023-08-01 | 2023-08-04 | A1890, A2040 | 52d | 0d |
| A2310 |  | Grava para drenaje | 3d | 2023-08-04 | 2023-08-08 | A1890, A2000 | 52d | 34d |
| A2010 |  | Relleno afirmado | 3d | 2023-08-12 | 2023-08-16 | A1770, A2050 | 74d | 36d |
|  | 3 | **Geotextil** |  | 2023-07-08 | 2023-08-08 |  |  |  |
| A2020 |  | Instalación de Geotextil - uña | 11d | 2023-07-08 | 2023-07-21 | A1970 SS+3d, A1780 | 60d | 4d |
| A2030 |  | Instalación de Geotextil - Talud | 6d | 2023-08-01 | 2023-08-08 | A1990 SS+6d, A1790 | 74d | 0d |
|  | 4 | **Colocación de Roca** |  | 2023-07-17 | 2023-08-12 |  |  |  |
| A2040 |  | Colocación de roca de uña | 7d | 2023-07-17 | 2023-07-25 | A2020 SS+3d, A1800 | 56d | 4d |
| A2050 |  | Colocación de roca de talud | 7d | 2023-08-04 | 2023-08-12 | A2030 SS+3d, A1810 | 74d | 0d |
|  | 7 | **DI-PR-41A-D** |  | 2023-06-22 | 2023-07-26 |  |  |  |
|  | 1 | **Excavaciones** |  | 2023-06-22 | 2023-06-28 |  |  |  |
| A1820 |  | Desbroce | 3d | 2023-06-22 | 2023-06-25 | A1940 | 23d | 0d |
| A1830 |  | Excavación de cimentación | 3d | 2023-06-22 | 2023-06-25 | A1820 SS, A1950 | 23d | 0d |
| A1835 |  | Excavación localizada - Sobreexcavación | 3d | 2023-06-22 | 2023-06-25 | A1830 SS | 130d |  |
| A1840 |  | Perfilado y conformación de plataforma de fundación | 2d | 2023-06-26 | 2023-06-28 | A1830 SS+3d, A1960 | 31d | 1d |
|  | 2 | **Rellenos** |  | 2023-07-19 | 2023-07-26 |  |  |  |
| A1860 |  | Relleno con material granular | 3d | 2023-07-19 | 2023-07-22 | A1840, A1980 | 14d | 0d |
| A1900 |  | Grava para drenaje | 3d | 2023-07-22 | 2023-07-26 | A1860 | 105d |  |
|  | 8 | **DI-PR-20-D** |  | 2023-06-26 | 2023-10-20 |  |  |  |
|  | 1 | **Excavaciones** |  | 2023-06-26 | 2023-08-25 |  |  |  |
| A2060 |  | Desbroce | 32d | 2023-06-26 | 2023-08-05 | A1820 | 23d | 0d |
| A2070 |  | Excavación de cimentación | 32d | 2023-06-26 | 2023-08-05 | A2060 SS, A1830 | 23d | 0d |
| A2075 |  | Excavación localizada - Sobreexcavación | 32d | 2023-06-26 | 2023-08-05 | A2070 SS | 98d |  |
| A2080 |  | Perfilado y conformación de plataforma de fundación | 30d | 2023-06-30 | 2023-08-06 | A2070 SS+3d, A1840 | 79d | 2d |
| A2090 |  | Excavación de uña | 38d | 2023-07-10 | 2023-08-25 | A2070 SS+6d, A1970 | 18d | 0d |

| ID | WBS | Activity | Duration | Start | Finish | Predecessors | Total float | Free float |
| --- | --- | --- | --- | --- | --- | --- | --- | --- |
|  | 2 | **Rellenos** |  | 2023-07-22 | 2023-10-20 |  |  |  |
| A2100 |  | Relleno con material granular | 49d | 2023-07-22 | 2023-09-21 | A2090 SS+3d, A1860 | 14d | 0d |
| A2105 |  | Relleno con material seleccionado | 49d | 2023-07-22 | 2023-09-21 | A2100 SS | 59d |  |
| A2110 |  | Perfilado de Talud del dique | 38d | 2023-08-08 | 2023-09-22 | A2100 SS+12d, A1990 | 25d | 0d |
| A2120 |  | Relleno sin compactar | 24d | 2023-09-18 | 2023-10-15 | A2310, A2160 | 18d | 0d |
| A2130 |  | Relleno afirmado | 8d | 2023-09-28 | 2023-10-07 | A2010, A2170 | 38d |  |
| A2320 |  | Grava para drenaje | 4d | 2023-10-16 | 2023-10-20 | A2120, A2100 | 18d | 0d |
|  | 3 | **Geotextil** |  | 2023-07-13 | 2023-09-23 |  |  |  |
| A2140 |  | Instalación de Geotextil - uña | 36d | 2023-07-13 | 2023-08-26 | A2090 SS+3d | 18d | 0d |
| A2150 |  | Instalación de Geotextil - Talud | 33d | 2023-08-15 | 2023-09-23 | A2110 SS+6d | 29d | 0d |
|  | 4 | **Colocación de Roca** |  | 2023-07-17 | 2023-09-28 |  |  |  |
| A2160 |  | Colocación de roca de uña | 51d | 2023-07-17 | 2023-09-17 | A2140 SS+3d | 18d | 0d |
| A2170 |  | Colocación de roca de talud | 34d | 2023-08-18 | 2023-09-28 | A2150 SS+3d | 29d | 0d |
|  | 9 | **DI-PR-19-D** |  | 2023-08-05 | 2023-11-05 |  |  |  |
|  | 1 | **Excavaciones** |  | 2023-08-05 | 2023-09-13 |  |  |  |
| A2180 |  | Desbroce | 11d | 2023-08-05 | 2023-08-18 | A2060 | 44d | 0d |
| A2190 |  | Excavación de cimentación | 11d | 2023-08-05 | 2023-08-18 | A2180 SS, A2070 | 44d | 0d |
| A2195 |  | Excavación localizada - Sobreexcavación | 11d | 2023-08-05 | 2023-08-18 | A2190 SS | 87d |  |
| A2200 |  | Perfilado y conformación de plataforma de fundación | 11d | 2023-08-09 | 2023-08-22 | A2190 SS+3d, A2080 | 77d |  |
| A2210 |  | Excavación de uña | 15d | 2023-08-25 | 2023-09-13 | A2190 SS+6d, A2090 | 33d | 0d |
|  | 2 | **Rellenos** |  | 2023-09-21 | 2023-11-05 |  |  |  |
| A2220 |  | Relleno con material granular | 21d | 2023-09-21 | 2023-10-15 | A2210 SS+3d, A2100 | 14d | 0d |
| A2225 |  | Relleno con material seleccionado | 21d | 2023-09-21 | 2023-10-15 | A2220 SS | 38d |  |
| A2230 |  | Perfilado de Talud del dique | 13d | 2023-10-05 | 2023-10-20 | A2220 SS+12d, A2110 | 14d | 0d |
| A2240 |  | Relleno sin compactar | 9d | 2023-10-20 | 2023-10-31 | A2320, A2280 | 18d | 0d |
| A2250 |  | Relleno afirmado | 4d | 2023-10-31 | 2023-11-05 | A2010, A2290 | 14d |  |
| A2330 |  | Grava para drenaje | 3d | 2023-10-31 | 2023-11-04 | A2220, A2240 | 22d |  |

| ID | WBS | Activity | Duration | Start | Finish | Predecessors | Total float | Free float |
| --- | --- | --- | --- | --- | --- | --- | --- | --- |
|  | 3 | **Geotextil** |  | 2023-08-29 | 2023-10-22 |  |  |  |
| A2260 |  | Instalación de Geotextil - uña | 14d | 2023-08-29 | 2023-09-15 | A2210 SS+3d, A2140 | 41d | 13d |
| A2270 |  | Instalación de Geotextil - Talud | 9d | 2023-10-12 | 2023-10-22 | A2230 SS+6d, A2150 | 14d | 0d |
|  | 4 | **Colocación de Roca** |  | 2023-09-18 | 2023-10-31 |  |  |  |
| A2280 |  | Colocación de roca de uña | 18d | 2023-09-18 | 2023-10-08 | A2260 SS+3d, A2160 | 28d | 10d |
| A2290 |  | Colocación de roca de talud | 13d | 2023-10-16 | 2023-10-31 | A2270 SS+3d, A2170 | 14d | 0d |
|  | 6 | **Obras Civiles** |  | 2023-04-28 | 2023-09-14 |  |  |  |
| A2300 |  | Obras Civiles - Paquete 02 (02 estructuras de cruce) | 50d | 2023-04-28 | 2023-06-27 | A1030 SS+6d | 122d |  |
| A2720 |  | Obras Civiles - Paquete 03 (11 estructuras de cruce) | 80d | 2023-06-08 | 2023-09-14 | A1050 SS+6d | 65d |  |
|  | 7 | **Accesos** |  | 2023-07-05 | 2023-09-28 |  |  |  |
| A2660 |  | Losa de concreto para accesos de mantenimiento - Paquete 03 (06 unidades) | 70d | 2023-07-05 | 2023-09-28 | A1740 | 46d |  |
|  | 8 | **Señalización** |  | 2023-04-01 | 2023-11-21 |  |  |  |
| A2700 |  | Señalización de obra | 192d | 2023-04-01 | 2023-11-21 | A1010 | 1d |  |
|  | 9 | **Calidad** |  | 2023-04-01 | 2023-11-21 |  |  |  |
| A2710 |  | Control de Calidad | 192d | 2023-04-01 | 2023-11-21 | A1010 | 1d |  |
